# Northfolk_09_ECE480

Schedule from MS Project, 2009-10-02 to 2009-12-11.
Michigan State University College of Engineering

## Calendars

- Standard: Mon-Fri 08:00-12:00, 13:00-17:00; Sat-Sun off.

## Schedule

| ID | Task | Duration | Start | Finish | Predecessors | Total slack | Free slack | Constraint |
| --- | --- | --- | --- | --- | --- | --- | --- | --- |
| 1 | Purchase Transducer | 7d | 2009-10-06 | 2009-10-14 |  | 0d |  | must start on 2009-10-06 |
| 2 | Design Classifier Hardware | 7d | 2009-10-02 | 2009-10-12 |  | 8d | 0d |  |
| 3 | Design Rod | 7d | 2009-10-02 | 2009-10-12 |  | 44d |  |  |
| 4 | Design Controls/Display | 7d | 2009-10-02 | 2009-10-12 |  | 8d | 0d |  |
| 5 | Assemble Test Bed | 2d | 2009-10-02 | 2009-10-05 |  | 9d |  |  |
| 6 | Assemble Basic Sensory Circuit | 2d | 2009-10-15 | 2009-10-16 | 1 | 0d |  |  |
| 7 | Obtain Spike Results | 2d | 2009-10-19 | 2009-10-20 | 6, 5 | 0d |  |  |
| 8 | Design Filter | 2d | 2009-10-21 | 2009-10-22 | 7 | 0d |  |  |
| 9 | Design Classifier Software | 2d | 2009-10-21 | 2009-10-22 | 7 | 4d |  |  |
| 10 | Design Power Systems | 2d | 2009-10-23 | 2009-10-26 | 8 | 7d | 0d |  |
| 11 | Build Filter | 1d | 2009-10-23 | 2009-10-23 | 8 | 0d |  |  |
| 12 | Build Classifier Hardware | 2d | 2009-10-13 | 2009-10-14 | 2 | 7d |  |  |
| 13 | Build Power Systems | 1d | 2009-10-27 | 2009-10-27 | 10 | 7d |  |  |
| 14 | Assmble Basic Prototype | 3d | 2009-10-26 | 2009-10-28 | 8, 11, 12, 15 | 0d |  |  |
| 15 | Build Controls | 1d | 2009-10-13 | 2009-10-13 | 4 | 8d |  |  |
| 16 | Test Prototype | 1d | 2009-10-29 | 2009-10-29 | 14, 9 | 0d |  |  |
| 17 | Refine Designs | 1d | 2009-10-30 | 2009-10-30 | 16 | 0d |  |  |
| 18 | Design Circuit Boards | 1d | 2009-11-02 | 2009-11-02 | 17 | 0d |  |  |
| 19 | Produce Circuit Boards | 2d | 2009-11-03 | 2009-11-04 | 18 | 0d |  |  |
| 20 | Solder Design together | 1d | 2009-11-05 | 2009-11-05 | 19 | 0d |  |  |
| 21 | Create Rod | 2d | 2009-11-03 | 2009-11-04 | 18 | 4d |  |  |
| 22 | Assemble Completed Components | 2d | 2009-11-06 | 2009-11-09 | 20, 13 | 0d |  |  |
| 23 | Test Final Design in Lab | 1d | 2009-11-10 | 2009-11-10 | 22 | 0d |  |  |
| 24 | Test Final design in real world | 1d | 2009-11-11 | 2009-11-11 | 23, 21 | 0d |  |  |
| 25 | Troubleshoot | 7d | 2009-11-12 | 2009-11-20 | 24 | 0d |  |  |
| 26 | Gather Performance Data | 4d | 2009-11-12 | 2009-11-17 | 24 | 18d |  |  |
| 27 | Create Presenation | 5d | 2009-11-12 | 2009-11-18 | 24 | 17d |  |  |
| 28 | Create Poster | 5d | 2009-11-12 | 2009-11-18 | 24 | 17d |  |  |
| 29 | Practice Presentation | 5d | 2009-11-12 | 2009-11-18 | 24 | 17d |  |  |
| 30 | Finalize All Components | 14d | 2009-11-23 | 2009-12-10 | 25 | 0d |  |  |
| 31 | Design Day | 1d? | 2009-12-11 | 2009-12-11 | 30 | 0d |  | must start on 2009-12-11 |
